# Seventec Propuesta

Schedule from MS Project, 2006-11-20 to 2007-05-07.
GlobalWebTek

## Calendars

- Standard: Mon-Fri 08:00-12:00, 13:00-17:00; Sat-Sun off. Exceptions (off unless hours are given): 2006-12-25, 2007-01-01, 2007-04-19, 2007-05-01.

## Resources

| Resource |
| --- |
| MR |
| HR |
| GP |
| R1 |
| R2 |
| S |
| OP |

## Schedule

| ID | WBS | Task | Type | Duration | Start | Finish | Predecessors | Total slack | Free slack | Constraint | Resources | Work |
| --- | --- | --- | --- | --- | --- | --- | --- | --- | --- | --- | --- | --- |
| 1 | 1 | **Proyecto e_Business DíaDía** |  | 116.75d | 2006-11-20 | 2007-05-07 |  | 0d |  |  |  | 1349h |
| 2 | 1.1 | **Inicio** |  | 0.25d | 2006-11-20 | 2006-11-20 |  | 116.5d |  |  |  | 4h |
| 3 | 1.1.1 | Reunión de Kickoff |  | 0.25d | 2006-11-20 | 2006-11-20 |  | 116.5d |  | start no earlier than 2006-11-20 | GP; R2 | 4h |
| 4 | 1.2 | **Levantamiento de Información General** |  | 0.5d | 2006-11-21 | 2006-11-21 |  | 115.25d |  |  |  | 12h |
| 5 | 1.2.1 | Sesión de Trabajo única (General de las tres Fases) |  | 0.5d | 2006-11-21 | 2006-11-21 |  | 115.25d |  | start no earlier than 2006-11-21 | GP; R1; R2 | 12h |
| 6 | 1.3 | **FASE I** |  | 36.17d | 2006-11-23 | 2007-01-16 |  | 77.58d |  |  |  | 408h |
| 7 | 1.3.1 | **Levantamiento de Información** |  | 2d | 2006-11-23 | 2006-11-24 |  | 77.58d |  |  |  | 32h |
| 8 | 1.3.1.1 | Sesión de Trabajo 1 |  | 1d | 2006-11-23 | 2006-11-23 |  | 77.58d | 0d | start no earlier than 2006-11-23 | GP; R1 | 16h |
| 9 | 1.3.1.2 | Sesión de Trabajo 2 |  | 1d | 2006-11-24 | 2006-11-24 | 8 | 77.58d | 0d | start no earlier than 2006-10-25 | GP; R1 | 16h |
| 10 | 1.3.2 | **Requerimientos, Análisis y Diseño** |  | 5d | 2006-11-27 | 2006-12-01 |  | 77.58d | 0d |  |  | 72h |
| 11 | 1.3.2.1 | Documento de Especificación de Requerimientos |  | 2d | 2006-11-27 | 2006-11-28 | 9 | 77.58d | 0d |  | GP | 16h |
| 12 | 1.3.2.2 | Ajustes Documento de Especificaciones |  | 0.5d | 2006-11-29 | 2006-11-29 | 11 | 77.58d | 0d |  | GP | 4h |
| 13 | 1.3.2.3 | Análisis y Diseño |  | 2d | 2006-11-29 | 2006-12-01 | 12 | 77.58d | 0d |  | GP; R1; R2 | 48h |
| 14 | 1.3.2.4 | Creación de Aplicación en N2C y WiB |  | 0.5d | 2006-12-01 | 2006-12-01 | 13 | 77.58d | 0d |  | OP | 4h |
| 15 | 1.3.3 | **Construcción** |  | 18d | 2006-12-04 | 2006-12-28 |  | 82.75d |  |  |  | 242h |
| 16 | 1.3.3.1 | **Diseño** |  | 4.25d | 2006-12-04 | 2006-12-08 |  | 98.5d | 0d |  |  | 34h |
| 17 | 1.3.3.1.1 | Diseño Gráfico |  | 2d | 2006-12-04 | 2006-12-05 | 14 | 98.5d | 0d |  | R2 | 16h |
| 18 | 1.3.3.1.2 | Presentación |  | 2h | 2006-12-06 | 2006-12-06 | 17 | 98.5d | 0d |  | R2 | 2h |
| 19 | 1.3.3.1.3 | Ajustes |  | 2d | 2006-12-06 | 2006-12-08 | 18 | 98.5d |  |  | R2 | 16h |
| 20 | 1.3.3.2 | Diseño Aprobado | milestone | 0d | 2006-12-08 | 2006-12-08 | 16 | 98.5d | 0d |  |  |  |
| 21 | 1.3.3.3 | **Construcción Funcionalidades** |  | 12d | 2006-12-04 | 2006-12-19 |  | 82.75d |  |  |  | 128h |
| 22 | 1.3.3.3.1 | Información Corporativa |  | 2d | 2006-12-08 | 2006-12-12 | 20 | 98.5d | 0d |  | R2 | 16h |
| 23 | 1.3.3.3.2 | Banner de Promociones |  | 2d | 2006-12-12 | 2006-12-14 | 22 | 98.5d |  |  | R2 | 16h |
| 24 | 1.3.3.3.3 | Noticias |  | 3d | 2006-12-04 | 2006-12-06 | 14 | 82.75d | 0d |  | R1 | 24h |
| 25 | 1.3.3.3.4 | Bolsa de Trabajo |  | 4d | 2006-12-07 | 2006-12-12 | 24 | 82.75d | 0d |  | R1 | 32h |
| 26 | 1.3.3.3.5 | Contáctenos |  | 5d | 2006-12-13 | 2006-12-19 | 25 | 82.75d | 0d |  | R1 | 40h |
| 27 | 1.3.3.4 | Pruebas Internas y Ajustes |  | 2d | 2006-12-20 | 2006-12-21 | 26 | 82.75d | 0d |  | GP; R1; R2 | 48h |
| 28 | 1.3.3.5 | Guías de Usuario |  | 4d | 2006-12-22 | 2006-12-28 | 27 | 82.75d | 0d |  | GP | 32h |
| 29 | 1.3.4 | Pruebas de Certificación |  | 2d | 2006-12-29 | 2007-01-02 | 28 | 82.75d | 1d |  | GP | 16h |

| ID | WBS | Task | Type | Duration | Start | Finish | Predecessors | Total slack | Free slack | Constraint | Resources | Work |
| --- | --- | --- | --- | --- | --- | --- | --- | --- | --- | --- | --- | --- |
| 30 | 1.3.5 | **Puesta en Marcha** |  | 4d | 2007-01-04 | 2007-01-09 |  | 81.75d | 0d |  |  | 32h |
| 31 | 1.3.5.1 | Adiestramiento WiB |  | 1d | 2007-01-04 | 2007-01-04 | 29 | 81.75d | 0d | start no earlier than 2007-01-04 | R2 | 8h |
| 32 | 1.3.5.2 | Adiestramiento Funcionalidades |  | 1d | 2007-01-05 | 2007-01-05 | 31 | 81.75d | 0d |  | GP | 8h |
| 33 | 1.3.5.3 | Implantación Fase I |  | 2d | 2007-01-08 | 2007-01-09 | 32 | 81.75d |  |  | OP | 16h |
| 34 | 1.3.6 | Seguimiento Fase I |  | 233.33h | 2006-12-04 | 2007-01-16 | 10 | 77.58d |  | finish no earlier than 2007-01-08 | GP [6%] | 14h |
| 35 | 1.3.7 | Fase I Concluida | milestone | 0d | 2007-01-09 | 2007-01-09 | 30 | 81.75d |  |  |  |  |
| 36 | 1.4 | **FASE II** |  | 39.17d | 2007-01-15 | 2007-03-09 |  | 39.58d |  |  |  | 410h |
| 37 | 1.4.1 | **Levantamiento de Información** |  | 2d | 2007-01-15 | 2007-01-16 |  | 48.5d | 0d |  |  | 40h |
| 38 | 1.4.1.1 | Sesión de Trabajo 1 |  | 1d | 2007-01-15 | 2007-01-15 |  | 48.5d | 0d | start no earlier than 2007-01-15 | GP; R1; R2 | 24h |
| 39 | 1.4.1.2 | Sesión de Trabajo 2 |  | 1d | 2007-01-16 | 2007-01-16 | 38 | 48.5d |  | start no earlier than 2007-01-08 | GP; R1 | 16h |
| 40 | 1.4.2 | **Requerimientos, Análisis y Diseño** |  | 5.5d | 2007-01-17 | 2007-01-24 |  | 48.5d |  |  |  | 76h |
| 41 | 1.4.2.1 | Documento de Especificación de Requerimientos |  | 2d | 2007-01-17 | 2007-01-18 | 37 | 48.5d | 0d |  | GP | 16h |
| 42 | 1.4.2.2 | Ajustes Documento de Especificaciones |  | 1d | 2007-01-19 | 2007-01-19 | 41 | 48.5d | 0d |  | GP | 8h |
| 43 | 1.4.2.3 | Análisis y Diseño |  | 2d | 2007-01-22 | 2007-01-23 | 42 | 48.5d | 0d |  | GP; R1; R2 | 48h |
| 44 | 1.4.2.4 | Creación de Aplicación en N2C y WiB |  | 0.5d | 2007-01-24 | 2007-01-24 | 43 | 48.5d | 0d |  | OP | 4h |
| 45 | 1.4.3 | **Construcción** |  | 18.5d | 2007-01-24 | 2007-02-19 |  | 49d |  |  |  | 242h |
| 46 | 1.4.3.1 | **Diseño** |  | 4.25d | 2007-01-24 | 2007-01-30 |  | 65.5d |  |  |  | 34h |
| 47 | 1.4.3.1.1 | Diseño Gráfico |  | 2d | 2007-01-24 | 2007-01-25 | 43 | 65.5d | 0d |  | R2 | 16h |
| 48 | 1.4.3.1.2 | Presentación |  | 2h | 2007-01-26 | 2007-01-26 | 47 | 65.5d | 0d |  | R2 | 2h |
| 49 | 1.4.3.1.3 | Ajustes |  | 2d | 2007-01-26 | 2007-01-30 | 48 | 65.5d | 0d |  | R2 | 16h |
| 50 | 1.4.3.2 | Diseño Aprobado | milestone | 0d | 2007-01-30 | 2007-01-30 | 49 | 65.5d | 0d |  |  |  |
| 51 | 1.4.3.3 | **Construcción Funcionalidades** |  | 15d | 2007-01-24 | 2007-02-14 |  | 48.5d |  |  |  | 136h |
| 52 | 1.4.3.3.1 | Noticias |  | 2d | 2007-01-30 | 2007-02-01 | 50 | 65.5d |  |  | R2 | 16h |
| 53 | 1.4.3.3.2 | Directorio de Trabajadores |  | 3d | 2007-01-24 | 2007-01-29 | 44 | 48.5d | 0d |  | R1 | 24h |
| 54 | 1.4.3.3.3 | Directorio de Tiendas |  | 3d | 2007-01-29 | 2007-02-01 | 53 | 48.5d | 0d |  | R1 | 24h |
| 55 | 1.4.3.3.4 | Gestión de Documentos |  | 4d | 2007-02-01 | 2007-02-07 | 54 | 48.5d | 0d |  | R1 | 32h |
| 56 | 1.4.3.3.5 | Indicadores de Desempeño |  | 5d | 2007-02-07 | 2007-02-14 | 55 | 48.5d | 0d |  | R1 | 40h |
| 57 | 1.4.3.4 | Pruebas Internas y Ajustes |  | 2d | 2007-02-14 | 2007-02-16 | 56 | 54.25d |  |  | GP; R1; R2 | 48h |
| 58 | 1.4.3.5 | Guías de Usuario |  | 3d | 2007-02-14 | 2007-02-19 | 56 | 48.5d | 0d |  | GP | 24h |
| 59 | 1.4.4 | Pruebas de Certificación |  | 2d | 2007-02-19 | 2007-02-21 | 58 | 48.25d | 0d |  | GP | 16h |

| ID | WBS | Task | Type | Duration | Start | Finish | Predecessors | Total slack | Free slack | Constraint | Resources | Work |
| --- | --- | --- | --- | --- | --- | --- | --- | --- | --- | --- | --- | --- |
| 60 | 1.4.5 | **Puesta en Marcha** |  | 2.75d | 2007-02-21 | 2007-02-26 |  | 48.5d |  |  |  | 22h |
| 61 | 1.4.5.1 | Adiestramiento WiB |  | 0.25d | 2007-02-21 | 2007-02-21 | 59 | 48.5d | 0d | start no earlier than 2007-01-04 | R2 | 2h |
| 62 | 1.4.5.2 | Adiestramiento Funcionalidades |  | 0.5d | 2007-02-21 | 2007-02-22 | 61 | 48.5d | 0d |  | GP | 4h |
| 63 | 1.4.5.3 | Implantación Fase I |  | 2d | 2007-02-22 | 2007-02-26 | 62 | 48.5d |  |  | OP | 16h |
| 64 | 1.4.6 | Seguimiento Fase II |  | 233.33h | 2007-01-29 | 2007-03-09 |  | 39.58d |  | start no earlier than 2007-01-29 | GP [6%] | 14h |
| 65 | 1.4.7 | Fase II Concluida | milestone | 0d | 2007-02-28 | 2007-02-28 |  | 46.75d |  | start no earlier than 2007-02-28 |  |  |
| 66 | 1.5 | **FASE III** |  | 35d | 2007-03-15 | 2007-05-04 |  | 0d |  |  |  | 449h |
| 67 | 1.5.1 | **Levantamiento de Información** |  | 2d | 2007-03-15 | 2007-03-16 |  | 1.62d |  |  |  | 40h |
| 68 | 1.5.1.1 | Sesión de Trabajo 1 |  | 1d | 2007-03-15 | 2007-03-15 |  | 1.62d | 0d | start no earlier than 2007-03-15 | GP; R1; R2 | 24h |
| 69 | 1.5.1.2 | Sesión de Trabajo 2 |  | 1d | 2007-03-16 | 2007-03-16 | 68 | 1.62d | 0d | start no earlier than 2007-01-08 | GP; R1 | 16h |
| 70 | 1.5.2 | **Requerimientos, Análisis y Diseño** |  | 5.5d | 2007-03-19 | 2007-03-26 |  | 1.62d |  |  |  | 76h |
| 71 | 1.5.2.1 | Documento de Especificación de Requerimientos |  | 2d | 2007-03-19 | 2007-03-20 | 69 | 1.62d | 0d |  | GP | 16h |
| 72 | 1.5.2.2 | Ajustes Documento de Especificaciones |  | 1d | 2007-03-21 | 2007-03-21 | 71 | 1.62d | 0d |  | GP | 8h |
| 73 | 1.5.2.3 | Análisis y Diseño |  | 2d | 2007-03-22 | 2007-03-23 | 72 | 1.62d | 0d |  | GP; R1; R2 | 48h |
| 74 | 1.5.2.4 | Creación de Aplicación en N2C y WiB |  | 0.5d | 2007-03-26 | 2007-03-26 | 73 | 1.62d | 0d |  | OP | 4h |
| 75 | 1.5.3 | **Construcción** |  | 24.5d | 2007-03-26 | 2007-04-30 |  | 2.12d |  |  |  | 282h |
| 76 | 1.5.3.1 | **Diseño** |  | 4.25d | 2007-03-26 | 2007-03-30 |  | 22.75d |  |  |  | 34h |
| 77 | 1.5.3.1.1 | Diseño Gráfico |  | 2d | 2007-03-26 | 2007-03-27 | 73 | 22.75d | 0d |  | R2 | 16h |
| 78 | 1.5.3.1.2 | Presentación |  | 2h | 2007-03-28 | 2007-03-28 | 77 | 22.75d | 0d |  | R2 | 2h |
| 79 | 1.5.3.1.3 | Ajustes |  | 2d | 2007-03-28 | 2007-03-30 | 78 | 22.75d | 0d |  | R2 | 16h |
| 80 | 1.5.3.2 | Diseño Aprobado | milestone | 0d | 2007-03-30 | 2007-03-30 | 79 | 22.75d | 0d |  |  |  |
| 81 | 1.5.3.3 | **Construcción Funcionalidades** |  | 18d | 2007-03-26 | 2007-04-20 |  | 1.62d |  |  |  | 152h |
| 82 | 1.5.3.3.1 | Noticias |  | 1d | 2007-03-30 | 2007-04-02 | 80 | 22.75d |  |  | R2 | 8h |
| 83 | 1.5.3.3.2 | Directorio de Proveedores |  | 3d | 2007-03-26 | 2007-03-29 | 74 | 1.62d | 0d |  | R1 | 24h |
| 84 | 1.5.3.3.3 | Estatus Proveedores |  | 15d | 2007-03-29 | 2007-04-20 | 83 | 1.62d | 0d |  | R1 | 120h |
| 85 | 1.5.3.4 | Pruebas Internas y Ajustes |  | 3d | 2007-04-20 | 2007-04-25 | 84 | 1.62d | 0d |  | GP; R1; R2 | 72h |
| 86 | 1.5.3.5 | Guías de Usuario |  | 3d | 2007-04-25 | 2007-04-30 | 85 | 3.5d |  |  | GP | 24h |
| 87 | 1.5.4 | Pruebas de Certificación |  | 2d | 2007-04-25 | 2007-04-27 | 85 | 1.38d | 0d |  | GP | 16h |

| ID | WBS | Task | Duration | Start | Finish | Predecessors | Total slack | Free slack | Constraint | Resources | Work |
| --- | --- | --- | --- | --- | --- | --- | --- | --- | --- | --- | --- |
| 88 | 1.5.5 | **Puesta en Marcha** | 2.75d | 2007-04-27 | 2007-05-03 |  | 1.62d |  |  |  | 22h |
| 89 | 1.5.5.1 | Adiestramiento WiB | 0.25d | 2007-04-27 | 2007-04-27 | 87 | 1.62d | 0d | start no earlier than 2007-01-04 | R2 | 2h |
| 90 | 1.5.5.2 | Adiestramiento Funcionalidades | 0.5d | 2007-04-27 | 2007-04-30 | 89 | 1.62d | 0d |  | GP | 4h |
| 91 | 1.5.5.3 | Implantación Fase I | 2d | 2007-04-30 | 2007-05-03 | 90 | 1.62d | 0d |  | OP | 16h |
| 92 | 1.5.6 | Seguimiento Fase III | 18.75d | 2007-04-06 | 2007-05-04 |  | 0d |  | finish no earlier than 2007-05-04 | GP [8%] | 12h |
| 93 | 1.5.7 | Fase III Concluida | 0.12d | 2007-05-03 | 2007-05-03 | 91 | 1.62d |  | start no earlier than 2007-03-28 |  | 1h |
| 94 | 1.6 | **Gerencia de Proyecto** | 116.75d | 2006-11-20 | 2007-05-07 |  | 0d |  |  |  | 66h |
| 95 | 1.6.1 | Planificación | 10d | 2006-11-20 | 2006-12-01 |  | 106.75d |  | start no earlier than 2006-11-20 | GP [25%] | 20h |
| 96 | 1.6.2 | Coordinación y administración | 62.5d | 2006-11-20 | 2007-02-16 |  | 54.25d |  | start no earlier than 2006-11-20 | GP [8%] | 40h |
| 97 | 1.6.3 | **Cierre** | 0.75d | 2007-05-07 | 2007-05-07 |  | 0d |  |  |  | 6h |
| 98 | 1.6.3.1 | Presentación Cierre de Proyecto | 0.5d | 2007-05-07 | 2007-05-07 | 66 | 0d |  |  | GP | 4h |
| 99 | 1.6.3.2 | Reunión Cierre de Proyecto | 2h | 2007-05-07 | 2007-05-07 | 98 | 0d |  |  | GP | 2h |
